# Proyecto de Ejemplo 1

Schedule from MS Project, 2024-10-01 to 2025-10-09, 6 hours a day.

## Calendars

- Calendario L-Mi-V: Mon 08:00-12:00, 13:00-15:00; Tue off; Wed 08:00-12:00, 13:00-15:00; Thu off; Fri 08:00-12:00, 13:00-15:00; Sat-Sun off. Exceptions (off unless hours are given): 2025-01-01 (Año Nuevo), 2025-01-06 (Dia de Reyes), 2025-01-21 (Virgen De La Altagracia), 2025-02-27 (Independencia Nacional), 2025-04-17 (Jueves Santos), 2025-04-18 (Viernes santos), 2025-05-01 (Dia Del Trabajador), 2025-06-19 (Corpus Christi), 2025-09-24 (Dia de La Mercedes).
- Calendario Ma y J: Mon off; Tue 08:00-12:00, 13:00-15:00; Wed off; Thu 08:00-12:00, 13:00-15:00; Fri-Sun off. Exceptions (off unless hours are given): 2025-01-01 (Año Nuevo), 2025-01-06 (Dia de Reyes), 2025-01-21 (Virgen De La Altagracia), 2025-02-27 (Independencia Nacional), 2025-04-17 (Jueves Santos), 2025-04-18 (Viernes Santos), 2025-05-01 (Dia Del Trabajador), 2025-06-19 (Corpus Christi), 2025-08-16 (Dia de la Restauracion), 2025-09-24 (Dia de Las Mercedes).
- Estándar con día feriados: Mon-Fri 09:00-13:00, 15:00-19:00; Sat-Sun off. Exceptions (off unless hours are given): 2025-01-01 (Año Nuevo), 2025-01-06 (Dia de Reyes), 2025-01-21 (Virgen de la Altagracia), 2025-02-27 (Independencia Nacional), 2025-04-17 (Jueves Santos), 2025-04-18 (Viernes Santos), 2025-05-01 (Dia del Trabajador), 2025-06-19 (Corpus Christi), 2025-09-24 (Dia de Las Mercedes).

## Resources

| Resource |
| --- |
| Hoyero 1 |
| Hoyero 2 |
| Hoyero 3 |
| Hoyero 4 |
| Hoyero 5 |
| Hoyero 6 |
| Hoyero 7 |
| Hoyero 8 |
| Hoyero 9 |
| Hoyero 10 |
| Grúa 1 |
| Grúa 2 |
| Grúa 3 |
| Grúa 4 |
| Grúa 5 |
| Canasto 1 |
| Canasto 2 |
| Canasto 3 |
| Canasto 4 |
| Canasto 5 |
| Canasto 6 |
| Canasto 7 |
| Canasto 8 |
| Canasto 9 |
| Canasto 10 |
| Brigada de Normalización 1 |
| Brigada de Normalización 2 |
| Brigada de Normalización 3 |
| Brigada de Normalización 4 |
| Brigada de Normalización 5 |
| Supervisor 1 |
| Supervisor 2 |
| Supervisor 3 |
| Supervisor 4 |
| Supervisor 5 |
| Supervisor 6 |
| Supervisor 7 |
| Supervisor 8 |
| Supervisor 9 |
| Supervisor 10 |
| Capataz 1 |
| Capataz 2 |
| Capataz 3 |
| Capataz 4 |
| Capataz 5 |
| Capataz 6 |
| Capataz 7 |
| Capataz 8 |
| Capataz 9 |
| Capataz 10 |
| Brigada de Poda 1 |
| Brigada de Poda 2 |
| Brigada de Poda 3 |
| Brigada de Poda 4 |
| Brigada de Poda 5 |
| Brigada de Poda 6 |
| Brigada de Poda 7 |
| Brigada de Poda 8 |
| Brigada de Poda 9 |
| Brigada de Poda 10 |
| Brigada Ligera 1 |
| Brigada Ligera 2 |
| Brigada Ligera 3 |
| Brigada Ligera 4 |
| Brigada Ligera 5 |
| Brigada Ligera 6 |
| Brigada Ligera 7 |
| Brigada Ligera 8 |
| Brigada Ligera 9 |
| Brigada Ligera 10 |
| Hoyero 1 A |
| Hoyero 2 B |
| Hoyero 3 C |
| Hoyero 4 D |
| Hoyero 5 E |
| Hoyero 6 F |
| Hoyero 7 G |
| Hoyero 8 H |
| Hoyero 9 I |
| Hoyero 10 J |
| Grúa 1 A |
| Grúa 2 B |
| Grúa 3 C |
| Grúa 4 D |
| Grúa 5 E |
| Canasto 1 A |
| Canasto 2 B |
| Canasto 3 C |
| Canasto 4 D |
| Canasto 5 E |
| Canasto 6 F |
| Canasto 7 G |
| Canasto 8 H |
| Canasto 9 I |
| Canasto 10 J |
| Brigada de Normalización 1 A |
| Brigada de Normalización 2 B |
| Brigada de Normalización 3 C |
| Brigada de Normalización 4 D |
| Brigada de Normalización 5 E |
| Brigada de Normalización 6 F |
| Brigada de Normalización 7 G |
| Brigada de Normalización 8 H |
| Brigada de Normalización 9 I |
| Brigada de Normalización 10 J |
| Supervisor 1 A |
| Supervisor 2 B |
| Supervisor 3 C |
| Supervisor 4 D |
| Supervisor 5 E |
| Supervisor 6 F |
| Supervisor 7 G |
| Supervisor 8 H |
| Supervisor 9 I |
| Supervisor 10 J |
| Capataz 1 A |
| Capataz 2 B |
| Capataz 3 C |
| Capataz 4 D |
| Capataz 5 E |
| Capataz 6 F |
| Capataz 7 G |
| Capataz 8 H |
| Capataz 9 I |
| Capataz 10 J |
| Brigada de Poda 1 A |
| Brigada de Poda 2 B |
| Brigada de Poda 3 C |
| Brigada de Poda 4 D |
| Brigada de Poda 5 E |
| Brigada de Poda 6 F |
| Brigada de Poda 7 G |
| Brigada de Poda 8 H |
| Brigada de Poda 9 I |
| Brigada de Poda 10 J |
| Brigada Ligera 1 A |
| Brigada Ligera 2 B |
| Brigada Ligera 3 C |
| Brigada Ligera 4 D |
| Brigada Ligera 5 E |
| Brigada Ligera 6 F |
| Brigada Ligera 7 G |
| Brigada Ligera 8 H |
| Brigada Ligera 9 I |
| Brigada Ligera 10 J |
| Hoyero 11 |
| Hoyero 12 |
| Hoyero 13 |
| Hoyero 14 |
| Hoyero 15 |
| Hoyero 11 K |
| Hoyero 12 L |
| Hoyero 13 M |
| Hoyero 14 N |
| Hoyero 15 Ñ |

## Schedule

| ID | WBS | Task | Duration | Start | Finish | Predecessors | Total slack | Free slack | Constraint | Calendar | Resources | Work | Días Calendario | Cantidad |
| --- | --- | --- | --- | --- | --- | --- | --- | --- | --- | --- | --- | --- | --- | --- |
| 1 | 1 | **Cronograma Lote-07 SAMA102CCA ANADEL SAMANA** | 344.67d | 2024-10-01 | 2025-10-09 |  | 0d |  |  | Estándar con día feriados |  | 9732h | 374días |  |
| 2 | 1.1 | **Preparativos previos Obras** | 44d | 2024-10-01 | 2024-11-14 |  | 2.67d |  |  | Estándar con día feriados |  |  | 45días |  |
| 3 | 1.1.1 | Reuniones con Contratista | 5d | 2024-10-01 | 2024-10-04 |  | 44d | 0d | start no earlier than 2024-10-01 | Estándar con día feriados |  |  | 4días |  |
| 4 | 1.1.2 | Revisiones adicionales de Ingenieria-Replanteo | 30d | 2024-10-07 | 2024-11-06 | 3FS+1d | 44d | 0d |  | Estándar con día feriados |  |  | 31días |  |
| 5 | 1.1.3 | Firma Minuta | 7d | 2024-11-07 | 2024-11-14 | 4FS+1d | 44d | 0d |  | Estándar con día feriados |  |  | 8días |  |
| 6 | 1.1.4 | Obtension Recursos Contratista | 30d | 2024-10-07 | 2024-11-06 |  | 352d |  | start no earlier than 2024-10-07 | Estándar con día feriados |  |  | 31días |  |
| 7 | 1.1.5 | Gestion de Materiales y Revision contra Fichas Tecnicas | 21d | 2024-10-07 | 2024-10-29 | 3FS+1d | 360.33d |  |  | Estándar con día feriados |  |  | 23días |  |
| 8 | 1.2 | **Suministro Materiales** | 119d | 2024-10-17 | 2025-02-24 |  | 209.67d |  |  | Estándar con día feriados |  |  | 131días |  |
| 9 | 1.2.1 | Suministro Postes | 90d | 2024-10-17 | 2025-01-23 | 4SS+10d | 252.33d | 0d |  | Estándar con día feriados |  |  | 99días |  |
| 10 | 1.2.2 | Suministro Armados | 90d | 2024-10-31 | 2025-02-06 | 9SS+14d | 252.33d | 0d |  | Estándar con día feriados |  |  | 99días |  |
| 11 | 1.2.3 | Suministro Tendido (Cables) | 90d | 2024-11-15 | 2025-02-24 | 10SS+15d | 252.33d | 0d |  | Estándar con día feriados |  |  | 102días |  |
| 12 | 1.2.4 | Suministro Transformadores | 90d | 2024-11-15 | 2025-02-24 | 11SS | 252.33d |  |  | Estándar con día feriados |  |  | 102días |  |
| 13 | 1.2.5 | Suministro Equipos Proteccion | 90d | 2024-11-15 | 2025-02-24 | 11SS | 252.33d |  |  | Estándar con día feriados |  |  | 102días |  |
| 14 | 1.2.6 | Suminiostro Alumbrado Publico | 90d | 2024-11-15 | 2025-02-24 | 11SS | 252.33d |  |  | Estándar con día feriados |  |  | 102días |  |
| 15 | 1.2.7 | Suministro Acometida y medidores | 90d | 2024-11-15 | 2025-02-24 | 11SS | 252.33d |  |  | Estándar con día feriados |  |  | 102días |  |
| 16 | 1.3 | **Ejecucion de Obras** | 136d | 2024-11-18 | 2025-10-09 |  | 0d |  |  |  |  | 9732h | 326días |  |
| 17 | 1.3.1 | **Poligono 1** | 94d | 2024-11-18 | 2025-06-30 |  | 8d |  |  |  |  | 3666h | 225días |  |
| 18 | 1.3.1.1 | Excavaciones | 12d | 2024-11-18 | 2024-12-13 | 5FS+1d | 27d | 0d |  |  | Hoyero 3; Hoyero 4; Hoyero 5; Hoyero 6; Hoyero 7; Hoyero 8; Hoyero 9; Hoyero 10; Hoyero 1; Hoyero 2; Hoyero 11; Hoyero 12; Hoyero 13; Hoyero 14; Hoyero 15 | 1080h | 26días | 734 |
| 19 | 1.3.1.2 | Izado de postes | 11d | 2024-11-18 | 2024-12-11 | 18SS | 27d | 0d |  |  | Grúa 3; Grúa 1; Grúa 2; Grúa 4; Grúa 5 | 330h | 24días | 370 |
| 20 | 1.3.1.3 | Cimentaciones | 6d | 2024-11-29 | 2024-12-11 | 19SS+5d | 125d |  |  |  | Brigada Ligera 1; Brigada Ligera 2 | 72h | 13días | 59 |
| 21 | 1.3.1.4 | Retenidas | 12d | 2024-11-25 | 2024-12-20 | 19SS+3d | 27d | 0d |  |  | Brigada Ligera 3; Canasto 1; Brigada Ligera 4; Brigada Ligera 5 | 288h | 26días | 364 |
| 22 | 1.3.1.5 | Armados MT y BT | 10d | 2024-12-23 | 2025-01-17 | 21 | 27d | 0d |  |  | Canasto 3; Canasto 4; Canasto 5; Canasto 2; Canasto 1 | 300h | 26días | 391 |
| 23 | 1.3.1.6 | Tendido de Conductor MT y BT | 14d | 2025-01-20 | 2025-02-19 | 22 | 27d | 0d |  |  | Canasto 3; Canasto 2; Canasto 1; Canasto 4; Canasto 5 | 420h | 31días | 24,625 |
| 24 | 1.3.1.7 | Puesta a Tierra | 4d | 2025-02-21 | 2025-02-28 | 23 | 27d | 0d |  |  | Canasto 5; Canasto 4; Canasto 1; Canasto 2; Canasto 3 | 120h | 8días | 220 |
| 25 | 1.3.1.8 | Conexiones y Jumper | 4d | 2025-03-03 | 2025-03-10 | 24 | 27d | 0d |  |  | Canasto 1; Canasto 2; Canasto 3; Canasto 4; Canasto 5 | 120h | 8días | 194 |
| 26 | 1.3.1.9 | Transformadores | 3d | 2025-03-12 | 2025-03-17 | 25 | 27d | 0d |  |  | Grúa 1; Canasto 1; Canasto 2; Canasto 3; Grúa 2; Grúa 3; Canasto 4; Canasto 5; Grúa 4; Grúa 5 | 180h | 6días | 40 |
| 27 | 1.3.1.10 | Alumbrado Público | 4d | 2025-03-19 | 2025-03-26 | 26 | 27d | 0d |  |  | Canasto 2; Canasto 1; Canasto 3; Canasto 4; Canasto 5 | 120h | 8días | 271 |
| 28 | 1.3.1.11 | Etiquetas CT | 2d | 2025-03-28 | 2025-03-31 | 27 | 27d | 0d |  |  | Canasto 1; Canasto 2 | 24h | 4días | 40 |
| 29 | 1.3.1.12 | Totalizadores | 4d | 2025-04-02 | 2025-04-09 | 28 | 27d | 0d |  |  | Canasto 3; Canasto 4; Canasto 5 | 72h | 8días | 40 |
| 30 | 1.3.1.13 | Acometida | 27d | 2025-04-04 | 2025-06-06 | 29SS+1d | 61d | 0d |  |  | Brigada de Normalización 1; Brigada de Normalización 2 | 324h | 64días | 1,079 |
| 31 | 1.3.1.14 | Remoción | 9d | 2025-06-11 | 2025-06-30 | 30FS+1d | 61d |  |  |  | Canasto 1; Grúa 1; Grúa 2; Canasto 2 | 216h | 20días | 927 |

Notes:
- 19: No se le asigna canasto, pero requiere uno para apertura y cierre de seccionador

| ID | WBS | Task | Duration | Start | Finish | Predecessors | Total slack | Free slack | Calendar | Resources | Work | Días Calendario | Cantidad |
| --- | --- | --- | --- | --- | --- | --- | --- | --- | --- | --- | --- | --- | --- |
| 33 | 1.3.2 | **Poligono 2** | 88d | 2024-11-21 | 2025-10-09 |  | 0d |  | Calendario Ma y J |  | 4086h | 323días |  |
| 34 | 1.3.2.1 | Excavaciones | 14d | 2024-11-21 | 2025-01-07 | 5FS+1d | 0d |  | Calendario Ma y J | Hoyero 3 C; Hoyero 4 D; Hoyero 5 E; Hoyero 6 F; Hoyero 7 G; Hoyero 8 H; Hoyero 9 I; Hoyero 10 J; Hoyero 1 A; Hoyero 2 B; Hoyero 11 K; Hoyero 12 L; Hoyero 13 M; Hoyero 14 N; Hoyero 15 Ñ | 1260h | 48días | 839 |
| 35 | 1.3.2.2 | Izado de postes | 12d | 2024-11-21 | 2024-12-31 | 34SS | 0d |  | Calendario Ma y J | Grúa 3 C; Grúa 1 A; Grúa 2 B; Grúa 4 D; Grúa 5 E | 360h | 41días | 416 |
| 36 | 1.3.2.3 | Cimentaciones | 9d | 2024-12-03 | 2024-12-31 | 35SS+3d | 0d |  | Calendario Ma y J | Brigada Ligera 1 A; Brigada Ligera 2 B; Brigada Ligera 3 C; Brigada Ligera 4 D; Brigada Ligera 5 E | 270h | 29días | 227 |
| 37 | 1.3.2.4 | Retenidas | 8d | 2025-01-02 | 2025-01-30 | 36 | 0d |  | Calendario Ma y J | Brigada Ligera 2 B; Brigada Ligera 3 C; Canasto 1 A; Brigada Ligera 4 D; Brigada Ligera 5 E; Brigada Ligera 1 A | 288h | 29días | 423 |
| 38 | 1.3.2.5 | Armados MT y BT | 14d | 2025-02-04 | 2025-03-25 | 37 | 0d |  | Calendario Ma y J | Canasto 3 C; Canasto 4 D; Canasto 5 E; Canasto 2 B; Canasto 1 A | 420h | 50días | 574 |
| 39 | 1.3.2.6 | Tendido de Conductor MT y BT | 11d | 2025-03-27 | 2025-05-08 | 38 | 0d |  | Calendario Ma y J | Canasto 3 C; Canasto 4 D; Canasto 5 E; Canasto 1 A; Canasto 2 B | 330h | 43días | 19,688 |
| 40 | 1.3.2.7 | Puesta a Tierra | 6d | 2025-05-13 | 2025-05-29 | 39 | 0d |  | Calendario Ma y J | Canasto 2 B; Canasto 3 C; Canasto 1 A; Canasto 4 D; Canasto 5 E | 180h | 17días | 318 |
| 41 | 1.3.2.8 | Conexiones y Jumper | 6d | 2025-06-03 | 2025-06-24 | 40 | 0d |  | Calendario Ma y J | Canasto 5 E; Canasto 4 D; Canasto 1 A; Canasto 2 B; Canasto 3 C | 180h | 22días | 306 |
| 42 | 1.3.2.9 | Transformadores | 2d | 2025-06-26 | 2025-07-01 | 41 | 0d |  | Calendario Ma y J | Grúa 2 B; Grúa 3 C; Canasto 1 A; Canasto 2 B; Canasto 3 C; Grúa 1 A; Grúa 4 D; Grúa 5 E; Canasto 4 D; Canasto 5 E | 120h | 6días | 39 |
| 43 | 1.3.2.10 | Alumbrado Público | 5d | 2025-07-03 | 2025-07-17 | 42 | 0d |  | Calendario Ma y J | Canasto 5 E; Canasto 4 D; Canasto 1 A; Canasto 2 B; Canasto 3 C | 150h | 15días | 398 |
| 44 | 1.3.2.11 | Etiquetas CT | 1d | 2025-07-22 | 2025-07-22 | 43 | 0d |  | Calendario Ma y J | Canasto 2 B; Canasto 1 A; Canasto 3 C | 18h | 1días | 46 |
| 45 | 1.3.2.12 | Totalizadores | 3d | 2025-07-24 | 2025-07-31 | 44 | 0d |  | Calendario Ma y J | Canasto 1 A; Canasto 3 C; Canasto 2 B; Canasto 4 D; Canasto 5 E | 90h | 8días | 46 |
| 46 | 1.3.2.13 | Acometida | 15d | 2025-08-05 | 2025-09-23 | 45SS+3d | 0d |  | Calendario Ma y J | Brigada de Normalización 1 A; Brigada de Normalización 2 B | 180h | 50días | 592 |
| 47 | 1.3.2.14 | Remoción | 10d | 2025-09-09 | 2025-10-09 | 46SS+10d | 0d |  | Calendario Ma y J | Canasto 1 A; Canasto 2 B; Grúa 2 B; Grúa 1 A | 240h | 31días | 1,043 |
| 49 | 1.3.3 | **Poligono 3** | 115d | 2024-12-18 | 2025-09-17 |  | 8d |  |  |  | 1980h | 274días |  |
| 50 | 1.3.3.1 | Excavaciones | 5d | 2024-12-18 | 2024-12-27 | 18FS+1d | 118d | 0d |  | Hoyero 5; Hoyero 6; Hoyero 7; Hoyero 8; Hoyero 9; Hoyero 10; Hoyero 1; Hoyero 2; Hoyero 3; Hoyero 4; Hoyero 11; Hoyero 12; Hoyero 13; Hoyero 14; Hoyero 15 | 450h | 10días | 327 |
| 51 | 1.3.3.2 | Izado de postes | 5d | 2024-12-18 | 2024-12-27 | 50SS | 118d | 0d |  | Grúa 2; Grúa 3; Grúa 4; Grúa 5; Grúa 1 | 150h | 10días | 169 |
| 52 | 1.3.3.3 | Cimentaciones | 1d | 2024-12-27 | 2024-12-27 | 51SS+4d | 118d |  |  | Brigada Ligera 1; Brigada Ligera 2; Brigada Ligera 3; Brigada Ligera 4; Brigada Ligera 5 | 30h | 1días | 35 |
| 53 | 1.3.3.4 | Retenidas | 3d | 2025-04-02 | 2025-04-07 | 28 | 77d |  |  | Brigada Ligera 1; Brigada Ligera 2; Brigada Ligera 3; Brigada Ligera 4; Brigada Ligera 5; Canasto 1 | 108h | 6días | 158 |
| 54 | 1.3.3.5 | Armados MT y BT | 5d | 2025-04-11 | 2025-04-23 | 29 | 8d | 0d |  | Canasto 2; Canasto 3; Canasto 4; Canasto 5; Canasto 1 | 150h | 13días | 185 |
| 55 | 1.3.3.6 | Tendido de Conductor MT y BT | 6d | 2025-04-25 | 2025-05-07 | 54 | 8d | 0d |  | Canasto 2; Canasto 3; Canasto 4; Canasto 5; Canasto 1 | 180h | 13días | 11,238 |
| 56 | 1.3.3.7 | Puesta a Tierra | 4d | 2025-05-09 | 2025-05-16 | 55 | 8d | 0d |  | Canasto 3; Canasto 4; Canasto 5 | 72h | 8días | 120 |
| 57 | 1.3.3.8 | Conexiones y Jumper | 4d | 2025-05-19 | 2025-05-26 | 56 | 8d | 0d |  | Canasto 3; Canasto 4; Canasto 5 | 72h | 8días | 118 |
| 58 | 1.3.3.9 | Transformadores | 2d | 2025-05-28 | 2025-05-30 | 57 | 8d | 0d |  | Canasto 4; Canasto 5; Grúa 4; Grúa 5; Grúa 3; Canasto 3 | 72h | 3días | 19 |
| 59 | 1.3.3.10 | Alumbrado Público | 2d | 2025-06-02 | 2025-06-04 | 58 | 8d | 0d |  | Canasto 4; Canasto 1; Canasto 2; Canasto 3; Canasto 5 | 60h | 3días | 150 |
| 60 | 1.3.3.11 | Etiquetas CT | 1d | 2025-06-06 | 2025-06-06 | 59 | 52d |  |  | Canasto 1; Canasto 2 | 12h | 1días | 19 |
| 61 | 1.3.3.12 | Totalizadores | 2d | 2025-06-06 | 2025-06-09 | 59 | 8d | 0d |  | Canasto 4; Canasto 5; Canasto 3 | 36h | 4días | 19 |
| 62 | 1.3.3.13 | Acometida | 41d | 2025-06-13 | 2025-09-15 | 61SS+3d | 8d | 0d |  | Brigada de Normalización 1; Brigada de Normalización 2 | 492h | 95días | 1,644 |
| 63 | 1.3.3.14 | Remoción | 4d | 2025-09-10 | 2025-09-17 | 62SS+38d | 8d |  |  | Canasto 1; Grúa 1; Grúa 2; Canasto 2 | 96h | 8días | 423 |

Notes:
- 35: No se le asigna canasto, pero requiere uno para apertura y cierre de seccionador
- 51: No se le asigna canasto, pero requiere uno para apertura y cierre de seccionador
